# SOX Compliance and Technology Options

Schedule from MS Project, 2007-04-02 to 2007-06-12.
Sarbanes-Oxley Section 404 Compliance required that most companies that report financial results after November 15, 2004 obtain an attestation from an outside auditor on the effectiveness of their internal controls. Some companies, in an effort to meet the deadline, put in place non-optimized and labor-intensive controls in order to meet the basic regulatory requirements. Many of these companies are now reviewing the controls put into place and evaluating potential technology options in an effort to make meeting this regulatory requirement less manual and more efficient. This template addresses the general activities that make up this process. This project assumes that the organization is already SOX compliant.

## Calendars

- Standard: Mon-Fri 08:00-12:00, 13:00-17:00; Sat-Sun off.

## Resources

| Resource |
| --- |
| External Auditing Firm |
| CFO |
| Accounting |
| IT Director / Manager |
| IT Applications Team |
| IT Network & Infrastructure Team |
| Operational Directors / Managers |
| SOX Compliance Team |
| Internal Audit Director |

## Schedule

| ID | WBS | Task | Type | Duration | Start | Finish | Predecessors | Total slack | Resources | Work |
| --- | --- | --- | --- | --- | --- | --- | --- | --- | --- | --- |
| 1 | 1 | **SOX Compliance Review Preparation** |  | 4d? | 2007-04-02 | 2007-04-05 |  | 0d |  | 104h |
| 2 | 1.1 | Meeting with the external audit firm |  | 1d? | 2007-04-02 | 2007-04-02 |  | 0d | External Auditing Firm | 8h |
| 3 | 1.2 | Define SOX compliance review roles and responsibilities |  | 1d | 2007-04-03 | 2007-04-03 | 2 | 0d | External Auditing Firm; Internal Audit Director; CFO | 24h |
| 4 | 1.3 | Define SOX compliance review and decision processes |  | 1d? | 2007-04-03 | 2007-04-03 | 3SS | 0d | External Auditing Firm; Internal Audit Director; CFO | 24h |
| 5 | 1.4 | Create SOX compliance review project plan |  | 1d? | 2007-04-04 | 2007-04-04 | 4 | 0d | External Auditing Firm; Internal Audit Director; CFO | 24h |
| 6 | 1.5 | Conduct kickoff meeting |  | 1d? | 2007-04-05 | 2007-04-05 | 5 | 0d | External Auditing Firm; Internal Audit Director; CFO | 24h |
| 7 | 1.6 | SOX Compliance Review Preparation Completed | milestone | 0d | 2007-04-05 | 2007-04-05 | 6 | 47.5d |  |  |
| 8 | 2 | **Initiation and Scope** |  | 4.5d? | 2007-04-06 | 2007-04-12 |  | 0d |  | 40h |
| 9 | 2.1 | Determine the systems and processes that are in scope |  | 0.5d? | 2007-04-06 | 2007-04-06 | 4, 6 | 0d | Accounting; SOX Compliance Team | 8h |
| 10 | 2.2 | Build communications plan for project participants and stakeholders |  | 1d? | 2007-04-06 | 2007-04-09 | 9 | 0d | SOX Compliance Team | 8h |
| 11 | 2.3 | Identify SOX training requirements for project participants |  | 1d? | 2007-04-09 | 2007-04-10 | 10 | 0d | SOX Compliance Team | 8h |
| 12 | 2.4 | Define project plan, key milestones, budget, and key project participants |  | 1d? | 2007-04-10 | 2007-04-11 | 11 | 0d | SOX Compliance Team | 8h |
| 13 | 2.5 | Define project progress reporting and structure for senior management |  | 1d? | 2007-04-11 | 2007-04-12 | 12 | 0d | SOX Compliance Team | 8h |
| 14 | 2.6 | Project Initiation Complete | milestone | 0d | 2007-04-12 | 2007-04-12 | 13 | 0d |  |  |
| 15 | 3 | **Review and Identify Improvement Opportunities** |  | 23d? | 2007-04-12 | 2007-05-15 |  | 0d |  | 616h |
| 16 | 3.1 | **Perform Risk Assessment** |  | 3d? | 2007-04-12 | 2007-04-17 |  | 0d |  | 24h |
| 17 | 3.1.1 | Review and confirm risk factors |  | 1d? | 2007-04-12 | 2007-04-13 | 14 | 0d | SOX Compliance Team | 8h |
| 18 | 3.1.2 | Validate probability and impact of risk factors |  | 1d? | 2007-04-13 | 2007-04-16 | 17 | 0d | SOX Compliance Team | 8h |
| 19 | 3.1.3 | Estimate and validate size and complexity of risk factors |  | 1d? | 2007-04-16 | 2007-04-17 | 18 | 0d | SOX Compliance Team | 8h |
| 20 | 3.2 | **Identify Significant Accounts and Internal Controls** |  | 1d? | 2007-04-17 | 2007-04-18 |  | 0d |  | 8h |
| 21 | 3.2.1 | Identify and validate application controls over the initiating, recording, processing, and reporting |  | 1d? | 2007-04-17 | 2007-04-18 | 19 | 0d | SOX Compliance Team | 8h |
| 22 | 3.3 | **Confirm General IT Controls** |  | 2d? | 2007-04-18 | 2007-04-20 |  | 0d |  | 184h |
| 23 | 3.3.1 | Review Security Policies and Procedures |  | 1d? | 2007-04-18 | 2007-04-19 | 21 | 0d | IT Network & Infrastructure Team; SOX Compliance Team | 16h |
| 24 | 3.3.2 | **Review Change Management Policies and Procedures** |  | 1d? | 2007-04-18 | 2007-04-19 |  | 0d |  | 48h |
| 25 | 3.3.2.1 | Review version management/release management procedures |  | 1d? | 2007-04-18 | 2007-04-19 | 23SS | 0d | IT Network & Infrastructure Team; SOX Compliance Team; IT Applications Team | 24h |
| 26 | 3.3.2.2 | Review source code/document version control procedures |  | 1d? | 2007-04-18 | 2007-04-19 | 23SS | 0d | IT Network & Infrastructure Team; SOX Compliance Team; IT Applications Team | 24h |
| 27 | 3.3.3 | Review Disaster Recovery Procedures |  | 1d? | 2007-04-18 | 2007-04-19 | 23SS | 0d | SOX Compliance Team; IT Network & Infrastructure Team | 16h |
| 28 | 3.3.4 | Review Backup and Recovery Procedures |  | 1d? | 2007-04-18 | 2007-04-19 | 23SS | 0d | SOX Compliance Team; IT Network & Infrastructure Team | 16h |
| 29 | 3.3.5 | Review Service-Level Agreement Policies |  | 1d? | 2007-04-18 | 2007-04-19 | 23SS | 0d | IT Network & Infrastructure Team; SOX Compliance Team; IT Applications Team; IT Director / Manager | 32h |
| 30 | 3.3.6 | Review Application Development and Coding Standards/Review Procedures |  | 1d? | 2007-04-18 | 2007-04-19 | 23SS | 0d | IT Applications Team; SOX Compliance Team | 16h |
| 31 | 3.3.7 | Review Testing Policies and Procedures |  | 1d? | 2007-04-18 | 2007-04-19 | 23SS | 0d | IT Applications Team; SOX Compliance Team | 16h |
| 32 | 3.3.8 | Review QA procedures |  | 1d? | 2007-04-18 | 2007-04-19 | 23SS | 0d | IT Applications Team; SOX Compliance Team | 16h |
| 33 | 3.3.9 | Summarize Improvement Opportunities Findings |  | 1d? | 2007-04-19 | 2007-04-20 | 23, 25, 26, 27, 28, 29, 30, 32, 31 | 0d | SOX Compliance Team | 8h |

Notes:
- 2: Subject of Meeting: / ·Issues. / ·Timing of the audit. / ·Required schedules and documents.
- 6: Subject of Meeting: / ·Assignment of duties. / ·Timing impacts and scheduling.

| ID | WBS | Task | Type | Duration | Start | Finish | Predecessors | Total slack | Resources | Work |
| --- | --- | --- | --- | --- | --- | --- | --- | --- | --- | --- |
| 34 | 3.4 | **Confirm Control Design** |  | 3d? | 2007-04-20 | 2007-04-25 |  | 0d |  | 64h |
| 35 | 3.4.1 | Identify policies and procedures |  | 1d? | 2007-04-20 | 2007-04-23 | 33 | 0d | SOX Compliance Team; Accounting | 16h |
| 36 | 3.4.2 | Review narratives and flowcharts |  | 1d? | 2007-04-23 | 2007-04-24 | 35 | 0d | SOX Compliance Team; Accounting | 16h |
| 37 | 3.4.3 | Review system configuration documentation |  | 1d | 2007-04-23 | 2007-04-24 | 36SS | 0d | SOX Compliance Team [200%]; IT Applications Team [200%] | 32h |
| 38 | 3.4.4 | Validate internal control checkpoints and processes |  | 1d? | 2007-04-24 | 2007-04-25 | 37 | 0d |  |  |
| 39 | 3.5 | **Evaluate Operational Effectiveness** |  | 3d? | 2007-04-25 | 2007-04-30 |  | 0d |  | 56h |
| 40 | 3.5.1 | Identify/confirm labor-intensive and cost-inefficient internal controls |  | 1d | 2007-04-25 | 2007-04-26 | 38 | 0d | SOX Compliance Team [12.5%]; Accounting [12.5%]; CFO [12.5%]; IT Director / Manager [12.5%]; Internal Audit Director [50%] | 8h |
| 41 | 3.5.2 | Prioritize inefficiencies - ongoing costs/internal control risks/cost and efficiency impacts |  | 1d? | 2007-04-26 | 2007-04-27 | 40 | 0d | Internal Audit Director; SOX Compliance Team; CFO | 24h |
| 42 | 3.5.3 | Develop cost estimates and efforts for prioritized improvement |  | 1d? | 2007-04-27 | 2007-04-30 | 41 | 0d | CFO; Internal Audit Director; SOX Compliance Team | 24h |
| 43 | 3.6 | **Finalize Cost/Benefit Analyses** |  | 11d? | 2007-04-30 | 2007-05-15 |  | 0d |  | 280h |
| 44 | 3.6.1 | Group improvements opportunities into technology improvement projects |  | 1d? | 2007-04-30 | 2007-05-01 | 42 | 0d | CFO; Internal Audit Director; SOX Compliance Team; IT Director / Manager; Accounting | 40h |
| 45 | 3.6.2 | Develop cost/benefit analyses |  | 1d? | 2007-05-01 | 2007-05-02 | 44 | 0d | CFO; Internal Audit Director; SOX Compliance Team; IT Director / Manager; Accounting | 40h |
| 46 | 3.6.3 | Develop future state scenarios and opportunity savings |  | 1d? | 2007-05-02 | 2007-05-03 | 45 | 0d | CFO; Internal Audit Director; SOX Compliance Team; IT Director / Manager; Accounting | 40h |
| 47 | 3.6.4 | Identify gaps |  | 1d? | 2007-05-03 | 2007-05-04 | 46 | 0d | CFO; Internal Audit Director; SOX Compliance Team; IT Director / Manager; Accounting | 40h |
| 48 | 3.6.5 | Identify project risks and impacts of doing nothing |  | 5d? | 2007-05-04 | 2007-05-11 | 47 | 0d | SOX Compliance Team | 40h |
| 49 | 3.6.6 | Identify additional key resources and information sources |  | 1d? | 2007-05-11 | 2007-05-14 | 48 | 0d | CFO; Internal Audit Director; SOX Compliance Team; IT Director / Manager; Accounting | 40h |
| 50 | 3.6.7 | Validate scope, participants and efforts |  | 1d? | 2007-05-14 | 2007-05-15 | 49 | 0d | CFO; Internal Audit Director; SOX Compliance Team; IT Director / Manager; Accounting | 40h |
| 51 | 3.7 | Improvement Design Complete | milestone | 0d | 2007-05-15 | 2007-05-15 | 50 | 20d |  |  |
| 52 | 4 | **Control Design** |  | 9d? | 2007-05-15 | 2007-05-28 |  | 0d |  | 176h |
| 53 | 4.1 | Project kickoff meeting |  | 1d? | 2007-05-15 | 2007-05-16 | 50 | 0d | SOX Compliance Team; IT Applications Team | 16h |
| 54 | 4.2 | Design new systems and cross-reference to related internal controls |  | 1d? | 2007-05-16 | 2007-05-17 | 53 | 0d | IT Applications Team; SOX Compliance Team | 16h |
| 55 | 4.3 | **Identify technologies that will be implemented** |  | 1d? | 2007-05-17 | 2007-05-18 |  | 0d |  | 48h |
| 56 | 4.3.1 | Identify data capture and editing systems |  | 1d? | 2007-05-17 | 2007-05-18 | 54 | 0d | IT Applications Team; SOX Compliance Team | 16h |
| 57 | 4.3.2 | Identify logging and monitoring systems |  | 1d? | 2007-05-17 | 2007-05-18 | 56SS | 0d | IT Applications Team; SOX Compliance Team | 16h |
| 58 | 4.3.3 | Identify analysis and reporting systems |  | 1d? | 2007-05-17 | 2007-05-18 | 56SS | 0d | IT Applications Team; SOX Compliance Team | 16h |
| 59 | 4.4 | Design necessary process changes |  | 1d? | 2007-05-18 | 2007-05-21 | 56, 57, 58 | 0d | IT Applications Team; SOX Compliance Team | 16h |
| 60 | 4.5 | Create policies, standards, and procedures |  | 1d? | 2007-05-21 | 2007-05-22 | 59 | 0d | IT Applications Team; SOX Compliance Team | 16h |
| 61 | 4.6 | Communicate changes that will required |  | 1d? | 2007-05-22 | 2007-05-23 | 60 | 0d | IT Applications Team; SOX Compliance Team | 16h |
| 62 | 4.7 | Identify appropriate frequency of control |  | 1d? | 2007-05-23 | 2007-05-24 | 61 | 0d | IT Applications Team; SOX Compliance Team | 16h |
| 63 | 4.8 | Finalize design |  | 1d? | 2007-05-24 | 2007-05-25 | 62 | 0d | IT Applications Team; SOX Compliance Team | 16h |
| 64 | 4.9 | Obtain approvals needed (SOX Compliance/Management) |  | 1d? | 2007-05-25 | 2007-05-28 | 63 | 0d | IT Applications Team; SOX Compliance Team | 16h |
| 65 | 4.10 | Control Design Complete | milestone | 0d | 2007-05-28 | 2007-05-28 | 64 | 0d | IT Applications Team; SOX Compliance Team |  |

| ID | WBS | Task | Type | Duration | Start | Finish | Predecessors | Total slack | Resources | Work |
| --- | --- | --- | --- | --- | --- | --- | --- | --- | --- | --- |
| 66 | 5 | **Development** |  | 3d? | 2007-05-28 | 2007-05-31 |  | 0d |  | 48h |
| 67 | 5.1 | Develop/implement redesigned systems and/or controls |  | 1d? | 2007-05-28 | 2007-05-29 | 65 | 0d | IT Applications Team; SOX Compliance Team | 16h |
| 68 | 5.2 | Re-communicate all changes to all impacted groups |  | 1d? | 2007-05-29 | 2007-05-30 | 67 | 0d | IT Applications Team; SOX Compliance Team | 16h |
| 69 | 5.3 | Validate internal controls maintained and/or improved |  | 1d? | 2007-05-30 | 2007-05-31 | 68 | 0d | IT Applications Team; SOX Compliance Team | 16h |
| 70 | 5.4 | Development complete | milestone | 0d | 2007-05-31 | 2007-05-31 | 69 | 0d |  |  |
| 71 | 6 | **Testing** |  | 4d? | 2007-05-31 | 2007-06-06 |  | 0d |  | 32h |
| 72 | 6.1 | Validate control effectiveness |  | 1d? | 2007-05-31 | 2007-06-01 | 70 | 0d | IT Applications Team | 8h |
| 73 | 6.2 | Document test cases/results in detailed test plans and summaries |  | 1d? | 2007-06-01 | 2007-06-04 | 72 | 0d | IT Applications Team | 8h |
| 74 | 6.3 | Validate improvement and/or remediation actions accomplished |  | 1d? | 2007-06-04 | 2007-06-05 | 73 | 0d | IT Applications Team | 8h |
| 75 | 6.4 | Document testing results |  | 1d? | 2007-06-05 | 2007-06-06 | 74 | 0d | IT Applications Team | 8h |
| 76 | 6.5 | Testing complete | milestone | 0d | 2007-06-06 | 2007-06-06 | 75 | 0d |  |  |
| 77 | 7 | **Implement** |  | 4d? | 2007-06-06 | 2007-06-12 |  | 0d |  | 112h |
| 78 | 7.1 | Update procedures and control documentation |  | 1d? | 2007-06-06 | 2007-06-07 | 76 | 0d | IT Applications Team; IT Network & Infrastructure Team; Accounting | 24h |
| 79 | 7.2 | Implement system changes |  | 1d? | 2007-06-07 | 2007-06-08 | 78 | 0d | IT Applications Team; IT Network & Infrastructure Team; Accounting | 24h |
| 80 | 7.3 | Monitor results and improvements |  | 1d? | 2007-06-08 | 2007-06-11 | 79 | 0d | Accounting; IT Applications Team; IT Network & Infrastructure Team; SOX Compliance Team | 32h |
| 81 | 7.4 | Document results and summarize to senior management |  | 1d? | 2007-06-11 | 2007-06-12 | 80 | 0d | Accounting; IT Applications Team; IT Network & Infrastructure Team; SOX Compliance Team | 32h |
| 82 | 7.5 | Implementation complete | milestone | 0d | 2007-06-12 | 2007-06-12 | 81 | 0d |  |  |
